# PlanNuevo Req FebV2

Schedule from MS Project, 2006-05-08 to 2006-06-20.
gm

## Calendars

- Estándar: Mon-Fri 09:00-13:00, 15:00-19:00; Sat-Sun off.

## Resources

| Resource |
| --- |
| R1 |
| R2 |
| Usuario |

## Schedule

| ID | WBS | Task | Duration | Start | Finish | Predecessors | Total slack | Free slack | Constraint | Resources | Work |
| --- | --- | --- | --- | --- | --- | --- | --- | --- | --- | --- | --- |
| 1 | 1 | **Nuevos requerimientos Génesis** | 32d? | 2006-05-08 | 2006-06-20 |  | 0d |  |  |  | 400h |
| 2 | 1.1 | **Área Comercial** | 31d | 2006-05-08 | 2006-06-19 |  | 0d |  |  |  | 272h |
| 3 | 1.1.1 | Tarifa: Manejo de Kms a exonerar por subgrupo | 5d | 2006-05-08 | 2006-05-12 |  | 0d |  | start no earlier than 2006-05-08 | R1 | 40h |
| 4 | 1.1.2 | Tarifa: Protección Amplia, Protección contra choque (con o sin) excluyentes | 5d | 2006-05-15 | 2006-05-19 | 3 | 0d |  |  | R1 | 40h |
| 5 | 1.1.3 | Cotización de varios carros con iguales condiciones | 4d | 2006-05-22 | 2006-05-25 | 4 | 0d |  | start no earlier than 2006-04-24 | R1 | 32h |
| 6 | 1.1.4 | Cotización: Cálculo de Impuesto | 4d | 2006-05-26 | 2006-05-31 | 5 | 0d |  |  | R1 | 32h |
| 7 | 1.1.5 | Reporte con vista al cliente de Subgrupo, marcas, modelos y datos de unidades | 3d | 2006-06-01 | 2006-06-05 | 6 | 0d |  |  | R1 | 24h |
| 8 | 1.1.6 | Reservación: Impresión de itinerarios de reserva para natural y jurídico por separados | 3d | 2006-06-06 | 2006-06-08 | 7 | 0d |  |  | R1 | 24h |
| 9 | 1.1.7 | Reporte Vendedoras | 4d | 2006-06-09 | 2006-06-14 | 8 | 0d |  |  | R1 | 32h |
| 10 | 1.1.8 | Pruebas Comercial | 3d | 2006-06-15 | 2006-06-19 | 9 | 0d |  |  | Usuario; R1 | 48h |
| 11 | 1.2 | **Área Operaciones** | 11d | 2006-05-08 | 2006-05-22 |  | 20d |  |  |  | 112h |
| 12 | 1.2.1 | Nueva vista de impresión de reporte para contrato | 4d | 2006-05-08 | 2006-05-11 |  | 20d | 0d | start no earlier than 2006-05-08 | R2 | 32h |
| 13 | 1.2.2 | Nuevo diseño Factura | 4d | 2006-05-12 | 2006-05-17 | 12 | 20d | 0d |  | R2 | 32h |
| 14 | 1.2.3 | Pruebas Operaciones | 3d | 2006-05-18 | 2006-05-22 | 13 | 20d |  |  | R2; Usuario | 48h |
| 15 | 1.3 | **Factura** | 1d? | 2006-05-23 | 2006-05-23 |  | 20d |  |  |  | 8h |
| 16 | 1.3.1 | Agregar fecha de Vencimiento a 30 días | 1d? | 2006-05-23 | 2006-05-23 | 14 | 20d |  |  | R2 | 8h |
| 17 | 1.4 | **Contrato y DR** | 1d? | 2006-06-20 | 2006-06-20 |  | 0d |  |  |  | 8h |
| 18 | 1.4.1 | Días de Crédito/Autorizar contratos | 1d? | 2006-06-20 | 2006-06-20 | 10 | 0d |  |  | R1 | 8h |
