# Plan New Light International_2005Sep29

Schedule from MS Project, 2006-07-03 to 2006-07-17.
GSM

## Calendars

- Standard: Mon-Fri 08:00-12:00, 13:00-17:00; Sat-Sun off.

## Resources

| Resource | Group |
| --- | --- |
| GWT Socio | GWT |
| GWT Lider Proyecto | GWT |
| GWT Analista 1 | GWT |
| GWT Analista 2 | GWT |
| DC Diseñador | DC |
| DC Lider Proyecto | DC |
| TN Lider Proyecto | TN |
| GWT Operaciones 1 | GWT |
| TN Operación 1 | TN |
| GWT Programador 1 | GWT |
| GWT Programador 2 | GWT |

## Schedule

| ID | WBS | Task | Duration | Start | Finish | Predecessors | Total slack | Free slack | Resources | Work |
| --- | --- | --- | --- | --- | --- | --- | --- | --- | --- | --- |
| 1 | GWT_DC_01.1 | **Proyecto DiChis** | 11d? | 2006-07-03 08:00 | 2006-07-17 17:00 |  | 0d |  |  | 12.9h |
| 2 | GWT_DC_01.1.30 | Gerencia de Proyectos | 8h? | 2006-07-03 08:00 | 2006-07-03 17:00 |  | 10d |  |  |  |
| 3 | GWT_DC_01.1.1 | **Operación, Mantenimiento y Soporte** | 7.5d? | 2006-07-03 08:00 | 2006-07-12 12:00 |  | 3.5d |  |  | 12.9h |
| 4 | GWT_DC_01.1.1.1 | Definición de configuración de servidores | 6h | 2006-07-03 08:00 | 2006-07-03 15:00 |  | 3.5d | 0d | GWT Operaciones 1; TN Operación 1; GWT Socio [15%] | 12.9h |
| 5 | GWT_DC_01.1.1.2 | Adquisición de servicios de hosting | 8h | 2006-07-03 15:00 | 2006-07-04 15:00 | 4 | 3.5d | 0d |  |  |
| 6 | GWT_DC_01.1.1.3 | Actualización de documento de configuración de servidores | 2h? | 2006-07-04 15:00 | 2006-07-04 17:00 | 5 | 3.5d | 0d |  |  |
| 7 | GWT_DC_01.1.1.4 | Adquisición e Instalación de PDFlib | 8h? | 2006-07-05 08:00 | 2006-07-05 17:00 | 6 | 3.5d | 0d |  |  |
| 8 | GWT_DC_01.1.1.5 | Instalación de N2C y WIB y librerías de manipulación de imágenes | 12h? | 2006-07-06 08:00 | 2006-07-07 12:00 | 7 | 3.5d | 0d |  |  |
| 9 | GWT_DC_01.1.1.6 | Adquisición y configuración de versión java de Aurigma | 16h? | 2006-07-07 13:00 | 2006-07-11 12:00 | 8 | 3.5d | 0d |  |  |
| 10 | GWT_DC_01.1.1.7 | Limpieza del URL para eliminar ZZZ... | 8h? | 2006-07-11 13:00 | 2006-07-12 12:00 | 9 | 3.5d |  |  |  |
| 11 | GWT_DC_01.1.2 | **Migración BD PHS a Servidor de desarrollo (integración de 4 aplicaciones en 1)** | 5.5d? | 2006-07-03 08:00 | 2006-07-10 12:00 |  | 5.5d |  |  |  |
| 12 | GWT_DC_01.1.2.1 | Reingeniería del Modelo de datos de BD incorporando ajustes para manejo de selecciones y blogs. | 16h? | 2006-07-03 08:00 | 2006-07-04 17:00 |  | 5.5d | 0d |  |  |
| 13 | GWT_DC_01.1.2.2 | Planificación de la migración | 4h? | 2006-07-05 08:00 | 2006-07-05 12:00 | 12 | 5.5d | 0d |  |  |
| 14 | GWT_DC_01.1.2.3 | Creación de tablas N2C a imagen de PHS con los cambios. OJO: e-MM Català en TRADUCCIONES | 24h? | 2006-07-05 13:00 | 2006-07-10 12:00 | 13 | 5.5d |  |  |  |
| 15 | GWT_DC_01.1.3 | **Migración aplicación PHS** | 11d? | 2006-07-03 08:00 | 2006-07-17 17:00 |  | 0d |  |  |  |
| 16 | GWT_DC_01.1.3.1 | Construcción de mapa de navegación de PHS / Casos de Uso | 40h? | 2006-07-03 08:00 | 2006-07-07 17:00 |  | 0d |  |  |  |
| 17 | GWT_DC_01.1.3.2 | Ajuste de programas de PHS a nuevas tablas | 24h? | 2006-07-10 08:00 | 2006-07-12 17:00 | 16 | 0d |  |  |  |
| 18 | GWT_DC_01.1.3.3 | Pantalla de unificación de funcionalidades de back office -al estilo WIB- Start page | 8h? | 2006-07-13 08:00 | 2006-07-13 17:00 | 17 | 0d |  |  |  |
| 19 | GWT_DC_01.1.3.4 | Verificación de funcionalidades de B.O. que se pueden probar hasta este punto. | 16h? | 2006-07-14 08:00 | 2006-07-17 17:00 | 18 | 0d |  |  |  |
| 20 | GWT_DC_01.1.4 | **Revisión y ajuste de programas recurrentes** | 1d? | 2006-07-03 08:00 | 2006-07-03 17:00 |  | 10d |  |  |  |
| 21 | GWT_DC_01.1.4.1 | arriba | 4h? | 2006-07-03 08:00 | 2006-07-03 12:00 |  | 10.5d |  |  |  |
| 22 | GWT_DC_01.1.4.2 | cabecera | 8h? | 2006-07-03 08:00 | 2006-07-03 17:00 |  | 10d |  |  |  |
| 23 | GWT_DC_01.1.4.3 | pie | 4h? | 2006-07-03 08:00 | 2006-07-03 12:00 |  | 10.5d |  |  |  |
| 24 | GWT_DC_01.1.5 | **Definición de L&F** | 1d? | 2006-07-03 08:00 | 2006-07-03 17:00 |  | 10d |  |  |  |
| 25 | GWT_DC_01.1.5.1 | Lineamientos de L&F a seguir en el site (reglas generales) | 8h? | 2006-07-03 08:00 | 2006-07-03 17:00 |  | 10d |  |  |  |

| ID | WBS | Task | Duration | Start | Finish | Total slack |
| --- | --- | --- | --- | --- | --- | --- |
| 26 | GWT_DC_01.1.6 | **Ajuste de páginas de contenido **** | 2d? | 2006-07-03 08:00 | 2006-07-04 17:00 | 9d |
| 27 | GWT_DC_01.1.6.1 | Definición de L&F | 8h? | 2006-07-03 08:00 | 2006-07-03 17:00 | 10d |
| 28 | GWT_DC_01.1.6.2 | Ajuste de L&F | 10h? | 2006-07-03 08:00 | 2006-07-04 10:00 | 9.75d |
| 29 | GWT_DC_01.1.6.3 | Actualización del contenido (ver anexo) | 16h? | 2006-07-03 08:00 | 2006-07-04 17:00 | 9d |
| 30 | GWT_DC_01.1.7 | **Ajuste de páginas con párrafos de aplicación** | 1.25d? | 2006-07-03 08:00 | 2006-07-04 10:00 | 9.75d |
| 31 | GWT_DC_01.1.7.1 | Definición de L&F | 8h? | 2006-07-03 08:00 | 2006-07-03 17:00 | 10d |
| 32 | GWT_DC_01.1.7.2 | Ajuste de L&F | 10h? | 2006-07-03 08:00 | 2006-07-04 10:00 | 9.75d |
| 33 | GWT_DC_01.1.7.3 | Revisión FAQ, Boletin | 8h? | 2006-07-03 08:00 | 2006-07-03 17:00 | 10d |
| 34 | GWT_DC_01.1.7.4 | Revisión de registro de usuarios | 8h? | 2006-07-03 08:00 | 2006-07-03 17:00 | 10d |
| 35 | GWT_DC_01.1.8 | **Módulo de Admin de Cliente (MAC)** | 3d? | 2006-07-03 08:00 | 2006-07-05 17:00 | 8d |
| 36 | GWT_DC_01.1.8.1 | Definición de L&F | 8h? | 2006-07-03 08:00 | 2006-07-03 17:00 | 10d |
| 37 | GWT_DC_01.1.8.2 | Ajuste de L&F | 24h? | 2006-07-03 08:00 | 2006-07-05 17:00 | 8d |
| 38 | GWT_DC_01.1.9 | **Upload de fotos** | 1d? | 2006-07-03 08:00 | 2006-07-03 17:00 | 10d |
| 39 | GWT_DC_01.1.9.1 | Definición de L&F | 8h? | 2006-07-03 08:00 | 2006-07-03 17:00 | 10d |
| 40 | GWT_DC_01.1.9.2 | Incorporación de Upload Aurigma en versión java. Considerar tiempo de investigación. | 5h? | 2006-07-03 08:00 | 2006-07-03 14:00 | 10.38d |
| 41 | GWT_DC_01.1.9.3 | Desactivar botón de envío por espacio insuficiente. | 3h? | 2006-07-03 08:00 | 2006-07-03 11:00 | 10.62d |
| 42 | GWT_DC_01.1.9.4 | Extraer metadata de las fotos al momento de la subida y asociarla al registro de la foto en BD (requiere investigación) | 8h? | 2006-07-03 08:00 | 2006-07-03 17:00 | 10d |
| 43 | GWT_DC_01.1.9.5 | Ajuste de L&F (versión java y tradicional) | 8h? | 2006-07-03 08:00 | 2006-07-03 17:00 | 10d |
| 44 | GWT_DC_01.1.10 | **Administración de Carpetas** | 1.88d? | 2006-07-03 08:00 | 2006-07-04 16:00 | 9.12d |
| 45 | GWT_DC_01.1.10.1 | Definición de L&F | 8h? | 2006-07-03 08:00 | 2006-07-03 17:00 | 10d |
| 46 | GWT_DC_01.1.10.2 | Revisión de opciones de administración de carpetas: renombrar carpeta, cambiar portada, copiar carpeta, eliminar carpeta | 8h? | 2006-07-03 08:00 | 2006-07-03 17:00 | 10d |
| 47 | GWT_DC_01.1.10.3 | Verificación de nombre de carpeta física versus nombre interno para evitar aborto de mkdir | 8h? | 2006-07-03 08:00 | 2006-07-03 17:00 | 10d |
| 48 | GWT_DC_01.1.10.4 | Eliminación de opción de compartir a nivel de carpeta | 4h? | 2006-07-03 08:00 | 2006-07-03 12:00 | 10.5d |
| 49 | GWT_DC_01.1.10.5 | Ajuste de L&F | 15h? | 2006-07-03 08:00 | 2006-07-04 16:00 | 9.12d |

| ID | WBS | Task | Duration | Start | Finish | Total slack |
| --- | --- | --- | --- | --- | --- | --- |
| 50 | GWT_DC_01.1.11 | **Administración de imágenes en carpetas** | 2.5d? | 2006-07-03 08:00 | 2006-07-05 12:00 | 8.5d |
| 51 | GWT_DC_01.1.11.1 | Definición de L&F | 8h? | 2006-07-03 08:00 | 2006-07-03 17:00 | 10d |
| 52 | GWT_DC_01.1.11.2 | Visualización de fotos: tamaño de visualización más grande, mostrar descripción de la foto. | 16h? | 2006-07-03 08:00 | 2006-07-04 17:00 | 9d |
| 53 | GWT_DC_01.1.11.3 | Revisión de opciones de administración de imágenes: renombrar imagen, copiar imagen, mover imagen, eliminar imagen, editar imagen. | 8h? | 2006-07-03 08:00 | 2006-07-03 17:00 | 10d |
| 54 | GWT_DC_01.1.11.4 | Detalle de foto: Edición de datos de foto, descarga de foto original, incluir metadata en datos desplegados, click sobre foto lleva a edición avanzada. | 20h? | 2006-07-03 08:00 | 2006-07-05 12:00 | 8.5d |
| 55 | GWT_DC_01.1.11.5 | Ajuste de L&F | 15h? | 2006-07-03 08:00 | 2006-07-04 16:00 | 9.12d |
| 56 | GWT_DC_01.1.12 | **Edición de imágenes** | 3d? | 2006-07-03 08:00 | 2006-07-05 17:00 | 8d |
| 57 | GWT_DC_01.1.12.1 | Definición de L&F | 8h? | 2006-07-03 08:00 | 2006-07-03 17:00 | 10d |
| 58 | GWT_DC_01.1.12.2 | Revisión de edición avanzada de fotos: Ojos rojos, Rotación, Efectos -blanco y negro / sepia- | 8h? | 2006-07-03 08:00 | 2006-07-03 17:00 | 10d |
| 59 | GWT_DC_01.1.12.3 | Ajuste de L&F | 24h? | 2006-07-03 08:00 | 2006-07-05 17:00 | 8d |
| 60 | GWT_DC_01.1.13 | **Administración de cuenta del cliente** | 2d? | 2006-07-03 08:00 | 2006-07-04 17:00 | 9d |
| 61 | GWT_DC_01.1.13.1 | Definición de L&F | 8h? | 2006-07-03 08:00 | 2006-07-03 17:00 | 10d |
| 62 | GWT_DC_01.1.13.2 | Ajuste de L&F | 16h? | 2006-07-03 08:00 | 2006-07-04 17:00 | 9d |
| 63 | GWT_DC_01.1.13.3 | Revisión de administración de cuenta del cliente | 8h? | 2006-07-03 08:00 | 2006-07-03 17:00 | 10d |
| 64 | GWT_DC_01.1.14 | **Libreta de contactos** | 3d? | 2006-07-03 08:00 | 2006-07-05 17:00 | 8d |
| 65 | GWT_DC_01.1.14.1 | Definición de L&F | 8h? | 2006-07-03 08:00 | 2006-07-03 17:00 | 10d |
| 66 | GWT_DC_01.1.14.2 | Ajustes de L&F | 24h? | 2006-07-03 08:00 | 2006-07-05 17:00 | 8d |
| 67 | GWT_DC_01.1.14.3 | Detectar que un agregado a la libreta de contactos está registrado y permitir incluirlo en un grupo | 4h? | 2006-07-03 08:00 | 2006-07-03 12:00 | 10.5d |
| 68 | GWT_DC_01.1.14.4 | Invitar a dichis.com | 8h? | 2006-07-03 08:00 | 2006-07-03 17:00 | 10d |
| 69 | GWT_DC_01.1.14.5 | Visualización, edición, creación y eliminación de grupos (1 grupo, Mis grupos) | 20h? | 2006-07-03 08:00 | 2006-07-05 12:00 | 8.5d |
| 70 | GWT_DC_01.1.15 | **Proyectos:** | 10d? | 2006-07-03 08:00 | 2006-07-14 17:00 | 1d |
| 71 | GWT_DC_01.1.15.1 | Reconsiderar L&F en todos los productos: Albumes, postales, regalos. | 54h? | 2006-07-03 08:00 | 2006-07-11 15:00 | 4.25d |
| 72 | GWT_DC_01.1.15.2 | Revisión de funcionalidad de todos los productos. | 80h? | 2006-07-03 08:00 | 2006-07-14 17:00 | 1d |
| 73 | GWT_DC_01.1.15.3 | Consideraciones de estampillado de productos | 8h? | 2006-07-03 08:00 | 2006-07-03 17:00 | 10d |
| 74 | GWT_DC_01.1.15.4 | Información adicional a ser incluida en el PDF o txt. Ejemplo: carta al usuario, etiqueta para el sobre ,etc. | 8h? | 2006-07-03 08:00 | 2006-07-03 17:00 | 10d |
| 75 | GWT_DC_01.1.15.5 | Pruebas de imprenta | 16h? | 2006-07-03 08:00 | 2006-07-04 17:00 | 9d |

| ID | WBS | Task | Duration | Start | Finish | Total slack |
| --- | --- | --- | --- | --- | --- | --- |
| 76 | GWT_DC_01.1.15.6 | **Albumes** | 3d? | 2006-07-03 08:00 | 2006-07-05 17:00 | 8d |
| 77 | GWT_DC_01.1.15.6.1 | Revisión de proceso de construcción del album. Considerar que una foto al ser seleccionada no debe desincorporarse del carrusel sino que debe ser marcada, de modo tal que pueda utilizarse en múltiples ocasiones | 24h? | 2006-07-03 08:00 | 2006-07-05 17:00 | 8d |
| 78 | GWT_DC_01.1.15.7 | **Gigantografías** | 8.75d? | 2006-07-03 08:00 | 2006-07-13 15:00 | 2.25d |
| 79 | GWT_DC_01.1.15.7.1 | Definición L&F | 8h? | 2006-07-03 08:00 | 2006-07-03 17:00 | 10d |
| 80 | GWT_DC_01.1.15.7.2 | Construcción de programa de pasos para elaboración de las gigantografías | 70h? | 2006-07-03 08:00 | 2006-07-13 15:00 | 2.25d |
| 81 | GWT_DC_01.1.15.7.3 | Construcción de PDF. Conexión con servidor de Mulá | 50h? | 2006-07-03 08:00 | 2006-07-11 10:00 | 4.75d |
| 82 | GWT_DC_01.1.16 | **Fotos sueltas (Quick shop)** | 2d? | 2006-07-03 08:00 | 2006-07-04 17:00 | 9d |
| 83 | GWT_DC_01.1.16.1 | Consideración de acabado mate y brillante* | 8h? | 2006-07-03 08:00 | 2006-07-03 17:00 | 10d |
| 84 | GWT_DC_01.1.16.2 | Definición de L&F | 8h? | 2006-07-03 08:00 | 2006-07-03 17:00 | 10d |
| 85 | GWT_DC_01.1.16.3 | Ajuste de L&F | 16h? | 2006-07-03 08:00 | 2006-07-04 17:00 | 9d |
| 86 | GWT_DC_01.1.17 | **Colecciones de Partners** | 5d? | 2006-07-03 08:00 | 2006-07-07 17:00 | 6d |
| 87 | GWT_DC_01.1.17.1 | Galería de Foto Mulá (sin descarga de originales) | 10h? | 2006-07-03 08:00 | 2006-07-04 10:00 | 9.75d |
| 88 | GWT_DC_01.1.17.2 | Definición de L&F | 8h? | 2006-07-03 08:00 | 2006-07-03 17:00 | 10d |
| 89 | GWT_DC_01.1.17.3 | Ajuste de L&F | 40h? | 2006-07-03 08:00 | 2006-07-07 17:00 | 6d |
| 90 | GWT_DC_01.1.18 | **Carrito de compras** | 5d? | 2006-07-03 08:00 | 2006-07-07 17:00 | 6d |
| 91 | GWT_DC_01.1.18.1 | Definición de L&F | 8h? | 2006-07-03 08:00 | 2006-07-03 17:00 | 10d |
| 92 | GWT_DC_01.1.18.2 | Ajuste de L&F | 40h? | 2006-07-03 08:00 | 2006-07-07 17:00 | 6d |
| 93 | GWT_DC_01.1.18.3 | Precio de envio (consideraciones de aliados) | 8h? | 2006-07-03 08:00 | 2006-07-03 17:00 | 10d |
| 94 | GWT_DC_01.1.18.4 | Excentar de IVA a países de L.A. | 8h? | 2006-07-03 08:00 | 2006-07-03 17:00 | 10d |
| 95 | GWT_DC_01.1.18.5 | Descablear precio de cuentas doradas | 8h? | 2006-07-03 08:00 | 2006-07-03 17:00 | 10d |
| 96 | GWT_DC_01.1.18.6 | Precio de fotografías de Galería FotoMulà para distintos productos | 32h? | 2006-07-03 08:00 | 2006-07-06 17:00 | 7d |
| 97 | GWT_DC_01.1.18.7 | Manejar métodos de pago: paypal -requiere investigación-, transferencia, tarjeta de crédito. | 40h? | 2006-07-03 08:00 | 2006-07-07 17:00 | 6d |
| 98 | GWT_DC_01.1.18.8 | Manejo de precios en dólares y euros | 16h? | 2006-07-03 08:00 | 2006-07-04 17:00 | 9d |
| 99 | GWT_DC_01.1.19 | **Reporte de Compras** | 1d? | 2006-07-03 08:00 | 2006-07-03 17:00 | 10d |
| 100 | GWT_DC_01.1.19.1 | Definición de L&F | 8h? | 2006-07-03 08:00 | 2006-07-03 17:00 | 10d |
| 101 | GWT_DC_01.1.19.2 | Ajuste de L&F | 8h? | 2006-07-03 08:00 | 2006-07-03 17:00 | 10d |

| ID | WBS | Task | Duration | Start | Finish | Total slack |
| --- | --- | --- | --- | --- | --- | --- |
| 102 | GWT_DC_01.1.20 | **Selecciones** | 8d? | 2006-07-03 08:00 | 2006-07-12 17:00 | 3d |
| 103 | GWT_DC_01.1.20.1 | Definición de L&F | 8h? | 2006-07-03 08:00 | 2006-07-03 17:00 | 10d |
| 104 | GWT_DC_01.1.20.2 | Creación de selección: desde la vista de la foto -fotos en conjunto o detalle-, desde la carpeta, desde el home o desde upload. Considerar portada, descripción y ordenamiento. | 40h? | 2006-07-03 08:00 | 2006-07-07 17:00 | 6d |
| 105 | GWT_DC_01.1.20.3 | Visualización del detalle y edición de imágenes en un FotoBlog: rotar, cambio de permisos, nombre, descripción, tags. Carrusel de fotos. Manejar los siguientes conceptos relativos a la foto: privada, pública, mis amigos, mis grupos. Tooltip | 64h? | 2006-07-03 08:00 | 2006-07-12 17:00 | 3d |
| 106 | GWT_DC_01.1.20.4 | Vista Estándar: despliegue por páginas de 20 fotos cada una. | 24h? | 2006-07-03 08:00 | 2006-07-05 17:00 | 8d |
| 107 | GWT_DC_01.1.20.5 | Vista blog (ver en una sola pantalla todas las fotos con sus comentarios -cuando la foto es comentable-) | 8h? | 2006-07-03 08:00 | 2006-07-03 17:00 | 10d |
| 108 | GWT_DC_01.1.20.6 | Incluir despliegue de comentarios (cuando la foto es comentable). Admisión de comentarios -permiso-. Opción para agregar comentarios. | 8h? | 2006-07-03 08:00 | 2006-07-03 17:00 | 10d |
| 109 | GWT_DC_01.1.20.7 | Eliminación de la foto de la selección | 8h? | 2006-07-03 08:00 | 2006-07-03 17:00 | 10d |
| 110 | GWT_DC_01.1.20.8 | Slideshow (investigación paquete existente) | 24h? | 2006-07-03 08:00 | 2006-07-05 17:00 | 8d |
| 111 | GWT_DC_01.1.20.9 | Vigencia de la visualización de una foto en una selección | 8h? | 2006-07-03 08:00 | 2006-07-03 17:00 | 10d |
| 112 | GWT_DC_01.1.20.10 | Vigencia de la selección para su visualización | 8h? | 2006-07-03 08:00 | 2006-07-03 17:00 | 10d |
| 113 | GWT_DC_01.1.20.11 | Descripción de la foto vinculada a la selección | 8h? | 2006-07-03 08:00 | 2006-07-03 17:00 | 10d |
| 114 | GWT_DC_01.1.21 | **FotoBlog** | 2.5d? | 2006-07-03 08:00 | 2006-07-05 12:00 | 8.5d |
| 115 | GWT_DC_01.1.21.1 | Definición de L&F | 8h? | 2006-07-03 08:00 | 2006-07-03 17:00 | 10d |
| 116 | GWT_DC_01.1.21.2 | Mecanismo de censura de fotos | 20h? | 2006-07-03 08:00 | 2006-07-05 12:00 | 8.5d |
| 117 | GWT_DC_01.1.21.3 | Slideshow (link) | 4h? | 2006-07-03 08:00 | 2006-07-03 12:00 | 10.5d |
| 118 | GWT_DC_01.1.21.4 | Acceso a través de URL al estilo www.dichis.com/login_cliente | 15h? | 2006-07-03 08:00 | 2006-07-04 16:00 | 9.12d |
| 119 | GWT_DC_01.1.22 | **Compartir: Selecciones** | 3d? | 2006-07-03 08:00 | 2006-07-05 17:00 | 8d |
| 120 | GWT_DC_01.1.22.1 | Definición de L&F | 8h? | 2006-07-03 08:00 | 2006-07-03 17:00 | 10d |
| 121 | GWT_DC_01.1.22.2 | Visualización de selecciones que he compartido. Filtros: compartidas por contactos, públicas, privadas. | 24h? | 2006-07-03 08:00 | 2006-07-05 17:00 | 8d |
| 122 | GWT_DC_01.1.22.3 | Mecanismo para compartir selecciones a imagen y semejanza de compartir de carpetas en PHS. | 16h? | 2006-07-03 08:00 | 2006-07-04 17:00 | 9d |
| 123 | GWT_DC_01.1.22.4 | Incluir invitación a registrarse en dichis.com desde la página que muestra las fotos del amigo cuando el invitado no está registrado. | 4h? | 2006-07-03 08:00 | 2006-07-03 12:00 | 10.5d |
| 124 | GWT_DC_01.1.22.5 | Guardar fechas de modificación de un blog y la fecha de última visita por parte de un contacto para notificar cambios. | 12h? | 2006-07-03 08:00 | 2006-07-04 12:00 | 9.5d |
| 125 | GWT_DC_01.1.23 | **Compartir: Proyectos** | 1d? | 2006-07-03 08:00 | 2006-07-03 17:00 | 10d |
| 126 | GWT_DC_01.1.23.1 | Revisar mecanismo actual para compartir proyectos | 8h? | 2006-07-03 08:00 | 2006-07-03 17:00 | 10d |

| ID | WBS | Task | Duration | Start | Finish | Total slack |
| --- | --- | --- | --- | --- | --- | --- |
| 127 | GWT_DC_01.1.24 | **Búsqueda de fotos** | 1d? | 2006-07-03 08:00 | 2006-07-03 17:00 | 10d |
| 128 | GWT_DC_01.1.24.1 | Búsqueda de fotos por tag en la cabecera de Mi Dichis | 8h? | 2006-07-03 08:00 | 2006-07-03 17:00 | 10d |
| 129 | GWT_DC_01.1.24.2 | Búsqueda avanzada utilizando: fecha, usuario, palabras clave, descripción, tamaños, tipo, resolución, precio, metadata. | 8h? | 2006-07-03 08:00 | 2006-07-03 17:00 | 10d |
| 130 | GWT_DC_01.1.25 | **Ampliación de estadísticas (BO)** | 1d? | 2006-07-03 08:00 | 2006-07-03 17:00 | 10d |
| 131 | GWT_DC_01.1.25.1 | Productos por categorías por partner. Ampliación de PHS | 8h? | 2006-07-03 08:00 | 2006-07-03 17:00 | 10d |
| 132 | GWT_DC_01.1.26 | **Enlatados** | 2.25d? | 2006-07-03 08:00 | 2006-07-05 10:00 | 8.75d |
| 133 | GWT_DC_01.1.26.1 | Definición de correos (enlatados) _idi | 18h? | 2006-07-03 08:00 | 2006-07-05 10:00 | 8.75d |
| 134 | GWT_DC_01.1.27 | **Pruebas** | 10d? | 2006-07-03 08:00 | 2006-07-14 17:00 | 1d |
| 135 | GWT_DC_01.1.27.1 | Internas | 80h? | 2006-07-03 08:00 | 2006-07-14 17:00 | 1d |
| 136 | GWT_DC_01.1.27.2 | De certificación | 80h? | 2006-07-03 08:00 | 2006-07-14 17:00 | 1d |
| 137 | GWT_DC_01.1.28 | Ajustes tras pruebas finales | 40h? | 2006-07-03 08:00 | 2006-07-07 17:00 | 6d |
| 140 | GWT_DC_01.1.29 | **Generales** | 1d? | 2006-07-03 08:00 | 2006-07-03 17:00 | 10d |
| 141 | GWT_DC_01.1.29.1 | Compatibilidad con Firefox | 8h? | 2006-07-03 08:00 | 2006-07-03 17:00 | 10d |
| 142 | GWT_DC_01.1.29.2 | Definición de templates para puesta al aire | 8h? | 2006-07-03 08:00 | 2006-07-03 17:00 | 10d |
| 143 | GWT_DC_01.1.29.3 | Redefinición del tamaño de las fotos de trabajo | 8h? | 2006-07-03 08:00 | 2006-07-03 17:00 | 10d |
| 144 | GWT_DC_01.1.29.4 | Redefinición del tamaño de thumbnail (para visualización y construcción de productos) | 8h? | 2006-07-03 08:00 | 2006-07-03 17:00 | 10d |
| 145 | GWT_DC_01.1.29.5 | Traducción de términos $MM. Manejo de catalán y español en principio | 8h? | 2006-07-03 08:00 | 2006-07-03 17:00 | 10d |
| 146 | GWT_DC_01.1.29.6 | Documentar código | 8h? | 2006-07-03 08:00 | 2006-07-03 17:00 | 10d |
