# Propuesta de Diseño

Schedule from MS Project, 2007-06-27 to 2007-08-31, A marks actual dates.
AMB Mercanet

## Calendars

- Estándar: Mon-Fri 09:00-13:00, 15:00-19:00; Sat-Sun off. Exceptions (off unless hours are given): 2007-07-05 (feriado), 2007-07-24 (feriado).

## Resources

| Resource |
| --- |
| AN |
| FA |
| LR |
| HR |
| OP |
| LR(50%) |
| GP |

## Schedule

| ID | WBS | Task | Type | Duration | Start | Finish | Predecessors | Complete | Remaining | Total slack | Free slack | Constraint | Resources | Work | Actual work |
| --- | --- | --- | --- | --- | --- | --- | --- | --- | --- | --- | --- | --- | --- | --- | --- |
| 1 | 1 | **Proyecto Sitio Web Día Día** |  | 46d | 2007-06-27 09:00 A | 2007-08-31 19:00 |  | 5% | 43.68d | 0d |  |  |  | 323h | 31.3h |
| 2 | 1.1 | Reunión Kickoff (Inicio Proyecto) |  | 0.38d | 2007-06-27 09:00 A | 2007-06-27 12:00 A |  | 100% |  |  |  |  | LR | 3h | 3h |
| 3 | 1.2 | Ajustes en el alcance y plan de actividades |  | 0.5d | 2007-06-28 09:00 A | 2007-06-28 13:00 A |  | 100% |  |  |  | start no earlier than 2007-06-28 09:00 | LR | 4h | 4h |
| 4 | 1.3 | **Levantamiento de Información** |  | 17.5d | 2007-07-04 09:00 A | 2007-07-31 13:00 |  | 45% | 9.55d | 23.5d |  |  |  | 18h | 10h |
| 5 | 1.3.1 | Sesión de Trabajo #1 |  | 0.42d | 2007-07-04 09:00 A | 2007-07-04 12:20 A |  | 100% |  |  |  | start no earlier than 2007-07-04 09:00 | FA; HR; LR | 10h | 10h |
| 6 | 1.3.2 | Sesión de Trabajo # 2 (Proveedores) |  | 0.5d | 2007-07-31 09:00 | 2007-07-31 13:00 |  |  |  | 23.5d |  | start no earlier than 2007-07-31 09:00 | AN; LR | 8h |  |
| 7 | 1.4 | **Informe de Especificación de Requerimientos** |  | 3d | 2007-08-01 09:00 | 2007-08-03 19:00 |  |  |  | 20d |  |  |  | 8h |  |
| 8 | 1.4.1 | Elaboración del Informe de Especificación de Requerimientos |  | 1d | 2007-08-01 09:00 | 2007-08-01 19:00 |  |  |  | 20d | 0d | start no earlier than 2007-08-01 09:00 | LR | 8h |  |
| 9 | 1.4.2 | Entrega al Equipo de Proyecto Día Día para su revisión | milestone | 0d | 2007-08-02 09:00 | 2007-08-02 09:00 | 8 |  |  | 20d | 0d | start no earlier than 2007-08-02 09:00 | LR |  |  |
| 10 | 1.4.3 | Revisión por parte del Equipo de Proyecto Día Día |  | 2d | 2007-08-02 09:00 | 2007-08-03 19:00 | 9 |  |  | 20d | 0d | start no earlier than 2007-06-06 09:00 |  |  |  |
| 11 | 1.4.4 | Aprobación del Informe Especificación de Requerimientos | milestone | 0d | 2007-08-03 19:00 | 2007-08-03 19:00 | 10 |  |  | 20d |  | start no earlier than 2007-06-15 09:00 |  |  |  |
| 12 | 1.5 | **Diseño Website e implementación WIB 5.0** |  | 25d | 2007-07-10 09:00 A | 2007-08-14 19:00 |  | 6% | 23.59d | 13d |  |  |  | 68h | 6h |
| 13 | 1.5.1 | **Diseño de Propuestas** |  | 2.25d | 2007-07-10 09:00 A | 2007-07-12 11:00 A |  | 100% |  |  |  |  |  | 6h | 6h |
| 14 | 1.5.1.1 | Diseño de Propuesta - Template 1 |  | 0.25d | 2007-07-10 09:00 A | 2007-07-10 11:00 A |  | 100% |  |  |  | start no earlier than 2007-07-10 09:00 | FA | 2h | 2h |
| 15 | 1.5.1.2 | Diseño de Propuesta - Template 2 |  | 0.25d | 2007-07-11 09:00 A | 2007-07-11 11:00 A |  | 100% |  |  |  | start no earlier than 2007-07-11 09:00 | FA | 2h | 2h |
| 16 | 1.5.1.3 | Diseño de Propuesta - Template 3 |  | 0.25d | 2007-07-12 09:00 A | 2007-07-12 11:00 A |  | 100% |  |  |  | start no earlier than 2007-07-12 09:00 | FA | 2h | 2h |
| 17 | 1.5.2 | **Revisión y Aprobación por parte del Cliente** |  | 7d | 2007-07-17 09:00 A | 2007-07-27 09:00 |  |  | 7d | 26d |  |  |  | 6h |  |
| 18 | 1.5.2.1 | Envío al Cliente para su revisión y aprobación | milestone | 0d | 2007-07-17 09:00 A | 2007-07-17 09:00 A |  | 100% |  |  |  | start no earlier than 2007-07-17 09:00 | LR |  |  |
| 19 | 1.5.2.2 | Revisión por parte del Cliente |  | 5d | 2007-07-17 09:00 | 2007-07-23 19:00 | 18 |  |  | 28d |  | start no earlier than 2007-07-17 09:00 |  |  |  |
| 20 | 1.5.2.3 | Reunión con el Cliente para revisión y emisión observaciones |  | 0.25d | 2007-07-23 09:00 | 2007-07-23 11:00 |  |  |  | 28.5d | 0d | start no earlier than 2007-07-23 09:00 | LR; FA | 4h |  |
| 21 | 1.5.2.4 | Ajustes y cambios finales propuestos por el Cliente |  | 0.25d | 2007-07-23 11:00 | 2007-07-23 13:00 | 20 |  |  | 28.5d |  |  | FA | 2h |  |
| 22 | 1.5.2.5 | Envío de Correcciones en formato Grafico (PNG) | milestone | 0d | 2007-07-25 09:00 | 2007-07-25 09:00 |  |  |  | 28d |  | start no earlier than 2007-07-25 09:00 | FA |  |  |
| 23 | 1.5.2.6 | Aprobación de Correcciones por parte del Cliente | milestone | 0d | 2007-07-27 09:00 | 2007-07-27 09:00 |  |  |  | 26d |  | start no earlier than 2007-07-27 09:00 |  |  |  |
| 24 | 1.5.3 | Creación del Sitio en WiB 5.0 - Dominio designado por el Cliente y N2C |  | 0.75d | 2007-07-25 09:00 | 2007-07-25 17:00 |  |  |  | 12.5d | 0d | start no earlier than 2007-07-25 09:00 | OP | 6h |  |

| ID | WBS | Task | Type | Duration | Start | Finish | Predecessors | Total slack | Free slack | Constraint | Resources | Work |
| --- | --- | --- | --- | --- | --- | --- | --- | --- | --- | --- | --- | --- |
| 25 | 1.5.4 | **Diseño de Hoja de Estilos** |  | 1.62d | 2007-07-25 17:00 | 2007-07-27 12:00 |  | 25.62d |  |  |  | 10h |
| 26 | 1.5.4.1 | Diseño y Prueba de Distribucion y Layout |  | 0.38d | 2007-07-25 17:00 | 2007-07-26 10:00 | 24 | 26.38d | 0d | start no earlier than 2007-07-25 09:00 | FA | 3h |
| 27 | 1.5.4.2 | Diseño y Prueba de Elementos HTML |  | 0.25d | 2007-07-26 10:00 | 2007-07-26 12:00 | 26 | 26.38d | 0d |  | FA | 2h |
| 28 | 1.5.4.3 | Diseño y Prueba de Clases y ID's |  | 0.25d | 2007-07-26 12:00 | 2007-07-26 16:00 | 27 | 26.38d |  |  | FA | 2h |
| 29 | 1.5.4.4 | Ajustes finales |  | 0.38d | 2007-07-27 09:00 | 2007-07-27 12:00 |  | 25.62d |  | start no earlier than 2007-07-27 09:00 | FA | 3h |
| 30 | 1.5.5 | Envío de textos a GWT para carga de contenido | milestone | 0d | 2007-07-27 09:00 | 2007-07-27 09:00 |  | 26d |  | start no earlier than 2007-07-27 09:00 |  |  |
| 31 | 1.5.6 | **Carga de Contenidos** |  | 2d | 2007-07-30 09:00 | 2007-07-31 19:00 |  | 22.5d |  |  |  | 16h |
| 32 | 1.5.6.1 | Carga de Texto en Home |  | 0.25d | 2007-07-30 09:00 | 2007-07-30 11:00 |  | 22.5d | 0d | start no earlier than 2007-07-30 09:00 | FA | 2h |
| 33 | 1.5.6.2 | Carga de Texto en Conoce DiaDia |  | 0.25d | 2007-07-30 11:00 | 2007-07-30 13:00 | 32 | 22.5d | 0d |  | FA | 2h |
| 34 | 1.5.6.3 | Carga de Texto en otras paginas |  | 0.38d | 2007-07-30 15:00 | 2007-07-30 18:00 | 33 | 22.5d | 0d |  | FA | 3h |
| 35 | 1.5.6.4 | Carga de Componentes en Home |  | 0.25d | 2007-07-30 18:00 | 2007-07-31 10:00 | 34 | 22.5d | 0d |  | FA | 2h |
| 36 | 1.5.6.5 | Carga de Componentes en Conoce DiaDia |  | 0.25d | 2007-07-31 10:00 | 2007-07-31 12:00 | 35 | 22.5d | 0d |  | FA | 2h |
| 37 | 1.5.6.6 | Carga de Componentes en otras paginas |  | 0.25d | 2007-07-31 12:00 | 2007-07-31 16:00 | 36 | 22.5d | 0d |  | FA | 2h |
| 38 | 1.5.6.7 | Ajustes finales en Home |  | 0.12d | 2007-07-31 16:00 | 2007-07-31 17:00 | 37 | 22.5d | 0d |  | FA | 1h |
| 39 | 1.5.6.8 | Ajustes finales en Conoce DiaDia |  | 0.12d | 2007-07-31 17:00 | 2007-07-31 18:00 | 38 | 22.5d | 0d |  | FA | 1h |
| 40 | 1.5.6.9 | Ajustes finales en otras Paginas |  | 0.12d | 2007-07-31 18:00 | 2007-07-31 19:00 | 39 | 22.5d | 0d |  | FA | 1h |
| 41 | 1.5.7 | **Creacion de Templates para el Home** |  | 1.5d | 2007-08-01 09:00 | 2007-08-02 13:00 |  | 21.5d |  |  |  | 8h |
| 42 | 1.5.7.1 | Creacion de Template 1 |  | 0.5d | 2007-08-01 09:00 | 2007-08-01 13:00 | 40 | 22.5d |  |  | FA | 4h |
| 43 | 1.5.7.2 | Creacion de Template 2 |  | 0.5d | 2007-08-02 09:00 | 2007-08-02 13:00 |  | 21.5d |  | start no earlier than 2007-08-02 09:00 | FA | 4h |
| 44 | 1.5.8 | **Correcciones Finales** |  | 2d | 2007-08-13 09:00 | 2007-08-14 19:00 |  | 13d |  |  |  | 16h |
| 45 | 1.5.8.1 | Revision de Look&Feel de Aplicaciones |  | 1d | 2007-08-13 09:00 | 2007-08-13 19:00 | 50 | 13d | 0d |  | FA; AN | 10h |
| 46 | 1.5.8.2 | Creacion de Documento de Estilo y alojamiento en FTP |  | 0.25d | 2007-08-14 09:00 | 2007-08-14 11:00 | 45 | 13d | 0d |  | FA | 2h |
| 47 | 1.5.8.3 | Pruebas de Descarga y Optimizacion final |  | 0.25d | 2007-08-14 11:00 | 2007-08-14 13:00 | 46 | 13d | 0d |  | FA | 2h |
| 48 | 1.5.8.4 | Actualizacion del Sitio |  | 0.25d | 2007-08-14 15:00 | 2007-08-14 17:00 | 47 | 13d | 0d |  | FA [50%] | 1h |
| 49 | 1.5.8.5 | Publicacion del Sitio en Modo Beta / Desarrollo |  | 0.25d | 2007-08-14 17:00 | 2007-08-14 19:00 | 48 | 13d |  |  | FA [50%] | 1h |

| ID | WBS | Task | Duration | Start | Finish | Predecessors | Complete | Remaining | Total slack | Free slack | Constraint | Resources | Work | Actual work |
| --- | --- | --- | --- | --- | --- | --- | --- | --- | --- | --- | --- | --- | --- | --- |
| 50 | 1.6 | **Configuración de Aplicaciones N2C** | 12.25d | 2007-07-25 17:00 A | 2007-08-10 19:00 |  | 6% | 11.55d | 13d | 0d |  |  | 98h | 5.6h |
| 51 | 1.6.1 | Contáctenos | 1d | 2007-07-25 17:00 A | 2007-07-26 17:00 | 24 | 70% | 0.3d | 13d | 0d |  | AN | 8h | 5.6h |
| 52 | 1.6.2 | Cuadro de Búsqueda | 0.25d | 2007-07-26 17:00 | 2007-07-26 19:00 | 51 |  |  | 13d |  |  | AN | 2h |  |
| 53 | 1.6.3 | Banners - Promociones | 1d | 2007-07-27 09:00 | 2007-07-27 19:00 | 52 |  |  | 13d |  |  | AN | 8h |  |
| 54 | 1.6.4 | Bolsa de Trabajo | 2d | 2007-07-30 09:00 | 2007-07-31 19:00 | 53 |  |  | 13d |  |  | AN | 16h |  |
| 55 | 1.6.5 | Sucursales (Dónde Estamos) | 2d | 2007-08-01 09:00 | 2007-08-02 19:00 | 54 |  |  | 13d | 0d |  | AN | 16h |  |
| 56 | 1.6.6 | Proveedores (Integración con Sistema Proveedores) | 5d | 2007-08-03 09:00 | 2007-08-09 19:00 | 55 |  |  | 13d | 0d |  | AN | 40h |  |
| 57 | 1.6.7 | Integración con WiB | 1d | 2007-08-10 09:00 | 2007-08-10 19:00 | 56 |  |  | 13d | 0d |  | AN | 8h |  |
| 58 | 1.7 | Ajustes de Aplicaciones WIB/N2C | 1d | 2007-08-13 09:00 | 2007-08-13 19:00 | 57 |  |  | 14d |  |  | FA; AN | 16h |  |
| 59 | 1.8 | Pruebas Internas | 9d | 2007-08-01 09:00 | 2007-08-13 19:00 |  |  |  | 13d | 0d | finish no earlier than 2007-08-13 19:00 | LR [11.1%] | 8h |  |
| 60 | 1.9 | Inducción (preparación y adiestramiento) | 0.5d | 2007-08-14 09:00 | 2007-08-14 13:00 | 59 |  |  | 13.5d |  |  | FA; LR | 8h |  |
| 61 | 1.10 | Pruebas de Certificación por parte del Cliente | 6d | 2007-08-13 09:00 | 2007-08-20 19:00 |  |  |  | 6d | 0d | finish no earlier than 2007-08-20 19:00 |  |  |  |
| 62 | 1.11 | Ajustes a las Aplicaciones y al Sitio | 3d | 2007-08-21 09:00 | 2007-08-23 19:00 | 61 |  |  | 6d |  |  | AN [33.3%]; FA [33.3%] | 16h |  |
| 63 | 1.12 | Documentación | 2d | 2007-08-27 09:00 | 2007-08-28 19:00 |  |  |  | 2d |  | start no earlier than 2007-08-27 09:00 | LR [50%] | 8h |  |
| 64 | 1.13 | Implementación (Pase a producción) | 1d | 2007-08-29 09:00 | 2007-08-29 19:00 | 63 |  |  | 2d |  | start no earlier than 2007-08-27 09:00 | OP | 8h |  |
| 65 | 1.14 | Gerencia de Proyecto | 45d | 2007-06-27 09:00 A | 2007-08-30 19:00 |  | 5% | 42.75d | 1d |  | start no earlier than 2007-06-27 09:00 | LR [15%] | 54h | 2.7h |
| 66 | 1.15 | Cierre | 1d | 2007-08-31 09:00 | 2007-08-31 19:00 |  |  |  | 0d |  | start no earlier than 2007-08-31 09:00 | LR [75%] | 6h |  |
