# Propuesta de Diseño

Schedule from MS Project, 2007-09-04 to 2007-11-01.
AMB Mercanet

## Calendars

- Estándar: Mon-Fri 09:00-13:00, 15:00-19:00; Sat-Sun off. Exceptions (off unless hours are given): 2007-10-12.

## Resources

| Resource |
| --- |
| FA |
| OP |
| GP |
| DS1 |
| DS3 |
| DS2 |

## Schedule

| ID | WBS | Task | Type | Duration | Start | Finish | Predecessors | Total slack | Free slack | Constraint | Resources | Work |
| --- | --- | --- | --- | --- | --- | --- | --- | --- | --- | --- | --- | --- |
| 1 | 1 | **Proyecto Sitio Web - Vida Profesional** |  | 41.75d? | 2007-09-04 | 2007-11-01 |  | 0d |  |  |  | 534h |
| 2 | 1.1 | Preparación y Reunión Kickoff (Inicio Proyecto) |  | 0.38d | 2007-09-04 | 2007-09-04 |  | 41.38d |  | start no earlier than 2007-09-04 | GP | 3h |
| 3 | 1.2 | Reservación dominio desarrollo, configuración y creación Sitio WIB |  | 0.5d? | 2007-09-10 | 2007-09-10 |  | 0d |  | start no earlier than 2007-09-10 | OP | 4h |
| 4 | 1.3 | Elaboración de Plan y Documento de Alcance |  | 1d? | 2007-09-10 | 2007-09-11 | 3 | 0.9d | 0d |  | GP [25%] | 2h |
| 5 | 1.4 | **Informe de Especificación de Requerimientos** |  | 6d | 2007-09-10 | 2007-09-18 |  | 0d |  |  |  | 16h |
| 6 | 1.4.1 | Elaboración del Informe de Especificación de Requerimientos |  | 4d | 2007-09-10 | 2007-09-14 | 3 | 0d |  | start no earlier than 2007-09-05 | GP [50%] | 16h |
| 7 | 1.4.2 | Entrega al Equipo de Proyecto Sodexho para su revisión | milestone | 0d | 2007-09-14 | 2007-09-14 | 6 | 0d |  | start no earlier than 2007-08-02 | GP |  |
| 8 | 1.4.3 | Revisión por parte del Equipo de Proyecto Sodexho |  | 2d | 2007-09-14 | 2007-09-18 | 7 | 0d |  | start no earlier than 2007-06-06 |  |  |
| 9 | 1.4.4 | Aprobación del Informe Especificación de Requerimientos | milestone | 0d | 2007-09-18 | 2007-09-18 | 8 | 0d |  | start no earlier than 2007-06-15 |  |  |
| 10 | 1.5 | **Diseño Website e implementación WIB** |  | 34d? | 2007-09-11 | 2007-10-30 |  | 2.25d |  |  |  | 136h |
| 11 | 1.5.1 | **WIB** |  | 25.5d? | 2007-09-11 | 2007-10-17 |  | 2.25d |  |  |  | 102h |
| 12 | 1.5.1.1 | **Diseño Pagina Principal** |  | 3d? | 2007-09-11 | 2007-09-14 |  | 2.25d | 0d |  |  | 12h |
| 13 | 1.5.1.1.1 | Proximos Eventos |  | 0.5d? | 2007-09-11 | 2007-09-11 | 4 | 2.25d | 0d |  | FA [50%] | 2h |
| 14 | 1.5.1.1.2 | Lo Ultimo |  | 0.5d? | 2007-09-12 | 2007-09-12 | 13 | 2.25d | 0d |  | FA [50%] | 2h |
| 15 | 1.5.1.1.3 | Enlaces a Salas |  | 0.5d? | 2007-09-12 | 2007-09-12 | 14 | 2.25d | 0d |  | FA [50%] | 2h |
| 16 | 1.5.1.1.4 | Calendario |  | 0.75d? | 2007-09-13 | 2007-09-13 | 15 | 2.25d | 0d |  | FA [50%] | 3h |
| 17 | 1.5.1.1.5 | Afiliados |  | 0.5d? | 2007-09-13 | 2007-09-14 | 16 | 2.25d | 0d |  | FA [50%] | 2h |
| 18 | 1.5.1.1.6 | Montaje Banner Principal elaborado por Sodexho |  | 0.25d? | 2007-09-14 | 2007-09-14 | 17 | 2.25d |  |  | FA [50%] | 1h |
| 19 | 1.5.1.2 | **Diseño Eventos** |  | 2.75d? | 2007-09-14 | 2007-09-19 |  | 2.25d | 0d |  |  | 11h |
| 20 | 1.5.1.2.1 | Listado de Eventos |  | 0.5d? | 2007-09-14 | 2007-09-14 | 12 | 2.25d | 0d |  | FA [50%] | 2h |
| 21 | 1.5.1.2.2 | Detalle de los Eventos |  | 0.5d? | 2007-09-17 | 2007-09-17 | 20 | 2.25d | 0d |  | FA [50%] | 2h |
| 22 | 1.5.1.2.3 | Planilla de Inscripción |  | 0.75d? | 2007-09-17 | 2007-09-18 | 21 | 2.25d | 0d |  | FA [50%] | 3h |
| 23 | 1.5.1.2.4 | Planilla de Pago |  | 1d? | 2007-09-18 | 2007-09-19 | 22 | 2.25d |  |  | FA [50%] | 4h |
| 24 | 1.5.1.3 | Mensaje de Información para Usuario |  | 0.5d? | 2007-09-19 | 2007-09-19 | 19 | 2.25d | 0d |  | FA [50%] | 2h |

| ID | WBS | Task | Duration | Start | Finish | Predecessors | Total slack | Free slack | Resources | Work |
| --- | --- | --- | --- | --- | --- | --- | --- | --- | --- | --- |
| 25 | 1.5.1.4 | **Diseño Salas** | 4.5d? | 2007-09-19 | 2007-09-26 |  | 2.25d | 0d |  | 18h |
| 26 | 1.5.1.4.1 | Descripcion de la Sala (Parrafo Libre) | 0.25d? | 2007-09-19 | 2007-09-19 | 24 | 2.25d | 0d | FA [50%] | 1h |
| 27 | 1.5.1.4.2 | Blog (Paquetizado) | 1d? | 2007-09-20 | 2007-09-20 | 26 | 2.25d | 0d | FA [50%] | 4h |
| 28 | 1.5.1.4.3 | Ultimos 6 Elementos de Información | 1.5d? | 2007-09-21 | 2007-09-24 | 27 | 2.25d | 0d | FA [50%] | 6h |
| 29 | 1.5.1.4.4 | **Buscador Avanzado** | 1.75d? | 2007-09-24 | 2007-09-26 |  | 2.25d |  |  | 7h |
| 30 | 1.5.1.4.4.1 | Formulario | 0.75d? | 2007-09-24 | 2007-09-25 | 28 | 2.25d | 0d | FA [50%] | 3h |
| 31 | 1.5.1.4.4.2 | Resultados | 1d? | 2007-09-25 | 2007-09-26 | 30 | 2.25d |  | FA [50%] | 4h |
| 32 | 1.5.1.5 | **Informacion Util** | 0.5d? | 2007-09-26 | 2007-09-26 |  | 2.25d | 0d |  | 2h |
| 33 | 1.5.1.5.1 | Informacion Util | 0.5d? | 2007-09-26 | 2007-09-26 | 25 | 2.25d |  | FA [50%] | 2h |
| 34 | 1.5.1.6 | **Servicios** | 2d? | 2007-09-26 | 2007-09-28 |  | 2.25d | 0d |  | 8h |
| 35 | 1.5.1.6.1 | Buscador | 1d? | 2007-09-26 | 2007-09-27 | 32 | 2.25d | 0d | FA [50%] | 4h |
| 36 | 1.5.1.6.2 | Pagina Detalle | 1d? | 2007-09-27 | 2007-09-28 | 35 | 2.25d |  | FA [50%] | 4h |
| 37 | 1.5.1.7 | Encabezado para Mail | 0.5d? | 2007-09-28 | 2007-10-01 | 34 | 2.25d | 0d | FA [50%] | 2h |
| 38 | 1.5.1.8 | **Formatos** | 0.5d? | 2007-10-01 | 2007-10-01 |  | 2.25d | 0d |  | 2h |
| 39 | 1.5.1.8.1 | Lista de documentos disponibles para ser descargados | 0.5d? | 2007-10-01 | 2007-10-01 | 37 | 2.25d |  | FA [50%] | 2h |
| 40 | 1.5.1.9 | **Herramientas** | 2.5d? | 2007-10-01 | 2007-10-04 |  | 2.25d | 0d |  | 10h |
| 41 | 1.5.1.9.1 | Calculadora de Inflacion | 1.25d? | 2007-10-01 | 2007-10-02 | 38 | 2.25d | 0d | FA [50%] | 5h |
| 42 | 1.5.1.9.2 | Calculadora Financiera | 1.25d? | 2007-10-03 | 2007-10-04 | 41 | 2.25d |  | FA [50%] | 5h |
| 43 | 1.5.1.10 | **Formularios** | 3d? | 2007-10-04 | 2007-10-09 |  | 2.25d | 0d |  | 12h |
| 44 | 1.5.1.10.1 | Formulario de Contacto | 1.5d? | 2007-10-04 | 2007-10-05 | 40 | 2.25d | 0d | FA [50%] | 6h |
| 45 | 1.5.1.10.2 | Formulario de Registro | 1.5d? | 2007-10-05 | 2007-10-09 | 44 | 2.25d |  | FA [50%] | 6h |
| 46 | 1.5.1.11 | **Mapa del Sitio** | 0.25d? | 2007-10-09 | 2007-10-09 |  | 2.25d | 0d |  | 1h |
| 47 | 1.5.1.11.1 | Mapa del Sitio | 0.25d? | 2007-10-09 | 2007-10-09 | 43 | 2.25d |  | FA [50%] | 1h |
| 48 | 1.5.1.12 | **Quien es Quien** | 0.5d? | 2007-10-09 | 2007-10-09 |  | 2.25d | 0d |  | 2h |
| 49 | 1.5.1.12.1 | Formato de Hoja de Vida | 0.5d? | 2007-10-09 | 2007-10-09 | 46 | 2.25d |  | FA [50%] | 2h |

| ID | WBS | Task | Duration | Start | Finish | Predecessors | Total slack | Free slack | Resources | Work |
| --- | --- | --- | --- | --- | --- | --- | --- | --- | --- | --- |
| 50 | 1.5.1.13 | **Encuestas** | 1d? | 2007-10-10 | 2007-10-10 |  | 2.25d | 0d |  | 4h |
| 51 | 1.5.1.13.1 | Formato de Encuestas | 1d? | 2007-10-10 | 2007-10-10 | 48 | 2.25d |  | FA [50%] | 4h |
| 52 | 1.5.1.14 | **Plantillas** | 4d? | 2007-10-11 | 2007-10-17 |  | 2.25d | 0d |  | 16h |
| 53 | 1.5.1.14.1 | Plantilla 1 | 1d? | 2007-10-11 | 2007-10-11 | 50 | 2.25d | 0d | FA [50%] | 4h |
| 54 | 1.5.1.14.2 | Plantilla 2 | 1d? | 2007-10-15 | 2007-10-15 | 53 | 2.25d | 0d | FA [50%] | 4h |
| 55 | 1.5.1.14.3 | Plantilla 3 | 1d? | 2007-10-16 | 2007-10-16 | 54 | 2.25d | 0d | FA [50%] | 4h |
| 56 | 1.5.1.14.4 | Plantilla 4 | 1d? | 2007-10-17 | 2007-10-17 | 55 | 2.25d |  | FA [50%] | 4h |
| 57 | 1.5.2 | **Net2Client** | 2.5d? | 2007-10-18 | 2007-10-22 |  | 2.25d | 0d |  | 10h |
| 58 | 1.5.2.1 | Revision y Adaptacion de CSS de Backoffice | 2.5d? | 2007-10-18 | 2007-10-22 | 52 | 2.25d |  | FA [50%] | 10h |
| 59 | 1.5.3 | Adaptacion de Hoja a Firefox | 6d? | 2007-10-22 | 2007-10-30 | 57 | 2.25d |  | FA [50%] | 24h |
| 60 | 1.6 | **Desarrollo y Configuración de Funcionalidades** | 29.23d? | 2007-09-11 | 2007-10-23 |  | 0.9d |  |  | 302h |
| 61 | 1.6.1 | **Análisis y Diseño de funcionalidades y backoffice** | 3.6d | 2007-09-11 | 2007-09-17 |  | 0.9d | 0d |  | 24h |
| 62 | 1.6.1.1 | Análisis | 1.6d | 2007-09-11 | 2007-09-13 | 4 | 0.9d | 0d | DS1; GP [25%] | 16h |
| 63 | 1.6.1.2 | Modelaje de Base de Datos | 2d | 2007-09-13 | 2007-09-17 | 62 | 1.82d |  | GP [25%]; DS1 | 8h |
| 64 | 1.6.2 | **Funcionalidades del Sitio Web** | 25.62d? | 2007-09-17 | 2007-10-23 |  | 1.82d | 0d |  | 278h |
| 65 | 1.6.2.1 | **BackOffice** | 10d? | 2007-09-17 | 2007-10-01 |  | 1.82d | 0d |  | 60h |
| 66 | 1.6.2.1.1 | Registro y Actualización de Cursos | 0.62d? | 2007-09-17 | 2007-09-17 | 61 | 11.2d | 0d | DS3 [80%] | 4h |
| 67 | 1.6.2.1.2 | Creación y Configuración de Salas | 1.25d? | 2007-09-17 | 2007-09-18 | 61 | 8.07d | 0d | DS1 [80%] | 8h |
| 68 | 1.6.2.1.3 | Artículos por Sala | 1.25d? | 2007-09-18 | 2007-09-19 | 67 | 8.07d | 0d | DS1 [80%] | 8h |
| 69 | 1.6.2.1.4 | Administración de Banners | 1.25d? | 2007-09-19 | 2007-09-24 | 68 | 6.07d |  | DS1 [80%] | 8h |
| 70 | 1.6.2.1.5 | Registro de Servicios | 1d? | 2007-09-17 | 2007-09-18 | 61 | 1.82d | 0d | DS2 [50%] | 4h |
| 71 | 1.6.2.1.6 | Manejo de Contenido de Artículos de Blogs | 4d | 2007-09-18 | 2007-09-26 | 70 | 1.82d | 0d | DS2 [50%] | 16h |
| 72 | 1.6.2.1.7 | Quién es Quién | 2d? | 2007-09-26 | 2007-09-28 | 71 | 1.82d | 0d | DS2 [50%] | 8h |
| 73 | 1.6.2.1.8 | Módulo Contáctenos | 1d? | 2007-09-28 | 2007-10-01 | 72 | 1.82d | 0d | DS2 [50%] | 4h |

| ID | WBS | Task | Duration | Start | Finish | Predecessors | Total slack | Free slack | Resources | Work |
| --- | --- | --- | --- | --- | --- | --- | --- | --- | --- | --- |
| 74 | 1.6.2.2 | **General** | 5d? | 2007-10-01 | 2007-10-08 |  | 1.82d |  |  | 43h |
| 75 | 1.6.2.2.1 | Registro de Cliente | 1.25d | 2007-10-01 | 2007-10-02 | 65 | 1.82d | 0d | DS1 [80%] | 8h |
| 76 | 1.6.2.2.2 | Login | 0.62d? | 2007-10-02 | 2007-10-02 | 75 | 1.82d | 0d | DS1 [80%] | 4h |
| 77 | 1.6.2.2.3 | Buscador General | 0.62d? | 2007-10-02 | 2007-10-03 | 76 | 1.82d | 0d | DS1 [80%] | 4h |
| 78 | 1.6.2.2.4 | Banners | 2.5d? | 2007-10-03 | 2007-10-08 | 77 | 1.82d | 0d | DS1 [80%] | 16h |
| 79 | 1.6.2.2.5 | Tópico de Interés | 0.62d? | 2007-10-01 | 2007-10-01 | 73 | 5.95d | 0d | DS2 [50%] | 2.5h |
| 80 | 1.6.2.2.6 | Encuestas | 1.25d? | 2007-10-01 | 2007-10-02 | 79 | 5.95d | 0d | DS2 [50%] | 5h |
| 81 | 1.6.2.2.7 | Contáctanos | 0.62d? | 2007-10-02 | 2007-10-03 | 80 | 5.95d | 0d | DS2 [50%] | 2.5h |
| 82 | 1.6.2.2.8 | Mapa del Sitio | 0.25d? | 2007-10-03 | 2007-10-03 | 81 | 5.95d | 0d | DS2 [50%] | 1h |
| 83 | 1.6.2.3 | **Página Principal** | 16.25d? | 2007-09-17 | 2007-10-09 |  | 4.32d |  |  | 46h |
| 84 | 1.6.2.3.1 | Lo que viene (despliegue de datos básicos de hasta 3 eventos) | 0.62d? | 2007-10-08 | 2007-10-08 | 78 | 1.82d | 0d | DS1 [80%] | 4h |
| 85 | 1.6.2.3.2 | Lo último (artículos de información recientes) | 0.62d? | 2007-10-08 | 2007-10-09 | 84 | 1.82d | 0d | DS1 [80%] | 4h |
| 86 | 1.6.2.3.3 | Enlaces a las salas | 0.62d? | 2007-10-09 | 2007-10-09 | 85 | 1.82d | 0d | DS1 [80%] | 4h |
| 87 | 1.6.2.3.4 | Afiliados (5 random) | 2.5d? | 2007-10-03 | 2007-10-08 | 82 | 5.95d | 0d | DS2 [50%] | 10h |
| 88 | 1.6.2.3.5 | Calendario de Eventos | 5d? | 2007-09-17 | 2007-09-24 | 66 | 14.32d | 0d | DS3 [60%] | 24h |
| 89 | 1.6.2.4 | **Eventos** | 7.5d? | 2007-09-24 | 2007-10-04 |  | 14.32d |  |  | 48h |
| 90 | 1.6.2.4.1 | Publicación de Cursos | 0.62d? | 2007-09-24 | 2007-09-25 | 88 | 14.32d | 0d | DS3 [80%] | 4h |
| 91 | 1.6.2.4.2 | Inscripción y registro de pago de cursos | 5.62d? | 2007-09-25 | 2007-10-02 | 90 | 14.32d | 0d | DS3 [80%] | 36h |
| 92 | 1.6.2.4.3 | Reservación y vencimiento | 1.25d? | 2007-10-02 | 2007-10-04 | 91 | 14.32d |  | DS3 [80%] | 8h |
| 93 | 1.6.2.5 | **Salas** | 8.5d? | 2007-10-08 | 2007-10-19 |  | 2.45d |  |  | 64h |
| 94 | 1.6.2.5.1 | Lo Último (los 6 elementos de información recientes) | 2.5d? | 2007-10-09 | 2007-10-15 | 86 | 1.82d | 0d | DS1 [80%] | 16h |
| 95 | 1.6.2.5.2 | Buscador | 3.75d? | 2007-10-15 | 2007-10-19 | 94 | 1.82d | 0d | DS1 [80%] | 24h |
| 96 | 1.6.2.5.3 | Artículo aleatorio en Columna Derecha | 0.62d? | 2007-10-19 | 2007-10-19 | 95 | 1.82d | 0d | DS1 [80%] | 4h |
| 97 | 1.6.2.5.4 | Blog | 2.5d? | 2007-10-08 | 2007-10-10 | 87 | 5.95d | 0d | DS2 [50%] | 10h |
| 98 | 1.6.2.5.5 | Quién es quién | 2.5d? | 2007-10-10 | 2007-10-16 | 97 | 5.95d | 0d | DS2 [50%] | 10h |

| ID | WBS | Task | Duration | Start | Finish | Predecessors | Total slack | Free slack | Resources | Work |
| --- | --- | --- | --- | --- | --- | --- | --- | --- | --- | --- |
| 99 | 1.6.2.6 | **Información Útil** | 5.38d? | 2007-10-16 | 2007-10-23 |  | 1.82d |  |  | 17h |
| 100 | 1.6.2.6.1 | Teléfonos (Página de Contenido) | 0.62d? | 2007-10-16 | 2007-10-16 | 98 | 5.95d | 0d | DS2 [50%] | 2.5h |
| 101 | 1.6.2.6.2 | Formatos | 0.62d? | 2007-10-16 | 2007-10-17 | 100 | 5.95d |  | DS2 [50%] | 2.5h |
| 102 | 1.6.2.6.3 | Herramientas | 0.62d? | 2007-10-19 | 2007-10-22 | 96 | 1.82d | 0d | DS1 [80%] | 4h |
| 103 | 1.6.2.6.4 | Servicios | 1.25d? | 2007-10-22 | 2007-10-23 | 102 | 1.82d |  | DS1 [80%] | 8h |
| 104 | 1.7 | Carga de datos de Clientes en .CSV | 3d? | 2007-10-23 | 2007-10-26 | 64 | 4.03d |  | GP [50%] | 12h |
| 105 | 1.8 | Pruebas Internas y ajustes | 0.95d | 2007-10-23 | 2007-10-24 | 64 | 1.82d | 0d | DS1; GP [5%] | 8h |
| 106 | 1.9 | Pruebas de Certificación por parte del Cliente | 3d | 2007-10-24 | 2007-10-29 | 105 | 1.82d | 0d |  |  |
| 107 | 1.10 | Implementación (Pase a producción) | 1d | 2007-10-29 | 2007-10-30 | 106 | 1.82d | 0d | OP | 8h |
| 108 | 1.11 | Guia de Usuario BackOffice | 2d | 2007-10-24 | 2007-10-26 | 105 | 3.07d | 0d | GP [50%] | 8h |
| 109 | 1.12 | Inducción (preparación y adiestramiento) | 1d | 2007-10-26 | 2007-10-29 | 108 | 3.07d |  | GP | 8h |
| 110 | 1.13 | **Gerencia de Proyectos** | 31.25d | 2007-09-18 | 2007-11-01 |  | 0d |  |  | 27h |
| 111 | 1.13.1 | Control y Seguimiento | 31.25d | 2007-09-18 | 2007-11-01 | 5 | 0d |  | GP [10%] | 25h |
| 112 | 1.13.2 | Cierre | 0.25d | 2007-10-30 | 2007-10-30 | 107 | 1.82d |  | GP | 2h |
