# Proyecto Vida Profesional

Schedule from MS Project, 2007-09-04 to 2007-11-27, A marks actual dates.

## Calendars

- Estándar: Mon-Fri 09:00-13:00, 15:00-19:00; Sat-Sun off. Exceptions (off unless hours are given): 2007-10-12.

## Resources

| Resource |
| --- |
| FA |
| OP |
| GP |
| DS1 |
| DS3 |
| DS2 |

## Schedule

| ID | WBS | Task | Type | Duration | Start | Finish | Predecessors | Complete | Remaining | Total slack | Free slack | Constraint | Resources | Work | Actual work |
| --- | --- | --- | --- | --- | --- | --- | --- | --- | --- | --- | --- | --- | --- | --- | --- |
| 1 | 1 | **Proyecto Sitio Web - Vida Profesional** |  | 59.21d? | 2007-09-04 A | 2007-11-27 |  | 35% | 38.2d? | 0d |  |  |  | 566h | 248.2h |
| 2 | 1.1 | Preparación y Reunión Kickoff (Inicio Proyecto) |  | 0.38d | 2007-09-04 A | 2007-09-04 A |  | 100% |  |  |  | start no earlier than 2007-09-04 | GP | 3h | 3h |
| 3 | 1.2 | Reservación dominio desarrollo, configuración y creación Sitio WIB |  | 0.5d? | 2007-09-10 A | 2007-09-10 A |  | 100% |  |  |  | start no earlier than 2007-09-10 | OP | 4h | 4h |
| 4 | 1.3 | Elaboración de Plan y Documento de Alcance |  | 1d? | 2007-09-10 A | 2007-09-11 A | 3 | 100% |  |  |  |  | GP [25%] | 2h | 2h |
| 5 | 1.4 | Ajustes Documento de Alcance y Plan |  | 1.25d? | 2007-09-18 A | 2007-09-19 A |  | 100% |  |  |  | start no earlier than 2007-09-18 | GP [10%]; FA [10%]; DS1 [10%] | 3h | 3h |
| 6 | 1.5 | **Informe de Especificación de Requerimientos** |  | 6d | 2007-09-19 A | 2007-09-27 A |  | 100% |  |  |  |  |  | 16h | 16h |
| 7 | 1.5.1 | Elaboración del Informe de Especificación de Requerimientos |  | 4d | 2007-09-19 A | 2007-09-25 A | 5 | 100% |  |  |  | start no earlier than 2007-09-05 | GP [50%] | 16h | 16h |
| 8 | 1.5.2 | Entrega al Equipo de Proyecto Sodexho para su revisión | milestone | 0d | 2007-09-25 A | 2007-09-25 A | 7 | 100% |  |  |  | start no earlier than 2007-08-02 | GP |  |  |
| 9 | 1.5.3 | Revisión por parte del Equipo de Proyecto Sodexho |  | 2d | 2007-09-25 A | 2007-09-27 A | 8 | 100% |  |  |  | start no earlier than 2007-06-06 |  |  |  |
| 10 | 1.5.4 | Aprobación del Informe Especificación de Requerimientos | milestone | 0d | 2007-09-27 A | 2007-09-27 A | 9 | 100% |  |  |  | start no earlier than 2007-06-15 |  |  |  |
| 11 | 1.6 | **Diseño Website e implementación WIB** |  | 47.97d? | 2007-09-11 A | 2007-11-16 |  | 37% | 30.05d? | 6.24d |  |  |  | 159h | 61h |
| 12 | 1.6.1 | **WIB** |  | 39.47d? | 2007-09-11 A | 2007-11-06 |  | 52% | 18.77d? | 6.24d | 0d |  |  | 125h | 61h |
| 13 | 1.6.1.1 | Creación y ajustes de Propuestas |  | 3.91d? | 2007-09-11 A | 2007-09-14 A |  | 100% |  |  |  | start no earlier than 2007-09-11 | FA [80%] | 25h | 25h |
| 14 | 1.6.1.2 | **Diseño Pagina Principal** |  | 3.5d? | 2007-09-14 A | 2007-09-20 A |  | 100% |  |  |  |  |  | 11h | 11h |
| 15 | 1.6.1.2.1 | Despliegue de Artículos (Lo último) |  | 0.31d? | 2007-09-14 A | 2007-09-17 A | 13 | 100% |  |  |  |  | FA [80%] | 2h | 2h |
| 16 | 1.6.1.2.2 | Artículo Aleatorio |  | 1d? | 2007-09-17 A | 2007-09-18 A | 15 | 100% |  |  |  |  |  | 1h | 1h |
| 17 | 1.6.1.2.3 | Despliegue de Banners |  | 0.16d? | 2007-09-19 A | 2007-09-19 A | 22 | 100% |  |  |  |  | FA [80%] | 1h | 1h |
| 18 | 1.6.1.2.4 | Calendario |  | 0.47d? | 2007-09-19 A | 2007-09-19 A | 17 | 100% |  |  |  |  | FA [80%] | 3h | 3h |
| 19 | 1.6.1.2.5 | Enlaces a Salas |  | 0.31d? | 2007-09-19 A | 2007-09-20 A | 18 | 100% |  |  |  |  | FA [80%] | 2h | 2h |
| 20 | 1.6.1.2.6 | Aliados |  | 0.31d? | 2007-09-20 A | 2007-09-20 A | 19 | 100% |  |  |  |  | FA [80%] | 2h | 2h |
| 21 | 1.6.1.3 | **Diseño Salas** |  | 6.09d? | 2007-09-18 A | 2007-09-26 |  | 78% | 1.35d? | 34.39d |  |  |  | 18h | 14h |
| 22 | 1.6.1.3.1 | Ultimos 6 Elementos de Información |  | 0.94d? | 2007-09-18 A | 2007-09-19 A | 16 | 100% |  |  |  |  | FA [80%] | 6h | 6h |
| 23 | 1.6.1.3.2 | Descripcion de la Sala (Parrafo Libre) |  | 0.16d? | 2007-09-20 A | 2007-09-20 A | 37 | 100% |  |  |  |  | FA [80%] | 1h | 1h |
| 24 | 1.6.1.3.3 | Blog (Paquetizado) |  | 0.62d? | 2007-09-20 A | 2007-09-21 A | 23 | 100% |  |  |  |  | FA [80%] | 4h | 4h |

| ID | WBS | Task | Duration | Start | Finish | Predecessors | Complete | Remaining | Total slack | Free slack | Constraint | Resources | Work | Actual work |
| --- | --- | --- | --- | --- | --- | --- | --- | --- | --- | --- | --- | --- | --- | --- |
| 25 | 1.6.1.3.4 | **Buscador Avanzado de Artículos** | 1.09d? | 2007-09-25 A | 2007-09-26 |  | 43% | 0.62d? | 34.39d |  |  |  | 7h | 3h |
| 26 | 1.6.1.3.4.1 | Formulario | 0.47d? | 2007-09-25 A | 2007-09-25 A | 44 | 100% |  |  |  |  | FA [80%] | 3h | 3h |
| 27 | 1.6.1.3.4.2 | Resultados | 0.62d? | 2007-09-25 | 2007-09-26 | 26 |  |  | 34.39d |  |  | FA [80%] | 4h |  |
| 28 | 1.6.1.4 | **Encuestas** | 1d? | 2007-09-28 A | 2007-10-01 A |  | 100% |  |  |  |  |  | 4h | 4h |
| 29 | 1.6.1.4.1 | Formato de Encuestas | 1d? | 2007-09-28 A | 2007-10-01 A |  | 100% |  |  |  |  | FA [50%] | 4h | 4h |
| 30 | 1.6.1.5 | **Mapa del Sitio** | 0.25d? | 2007-10-04 A | 2007-10-05 A |  | 100% |  |  |  |  |  | 1h | 1h |
| 31 | 1.6.1.5.1 | Mapa del Sitio | 0.25d? | 2007-10-04 A | 2007-10-05 A |  | 100% |  |  |  |  | FA [50%] | 1h | 1h |
| 32 | 1.6.1.6 | **Quien es Quien** | 0.5d? | 2007-10-05 A | 2007-10-05 A |  | 100% |  |  |  |  |  | 2h | 2h |
| 33 | 1.6.1.6.1 | Formato de Hoja de Vida | 0.5d? | 2007-10-05 A | 2007-10-05 A |  | 100% |  |  |  |  | FA [50%] | 2h | 2h |
| 34 | 1.6.1.7 | **Formularios** | 1.88d? | 2007-10-24 | 2007-10-25 |  |  |  | 11.8d | 0d |  |  | 12h |  |
| 35 | 1.6.1.7.1 | Formulario de Contacto | 0.94d? | 2007-10-24 | 2007-10-24 |  |  |  | 11.8d | 0d | start no earlier than 2007-10-24 | FA [80%] | 6h |  |
| 36 | 1.6.1.7.2 | Formulario de Registro | 0.94d? | 2007-10-24 | 2007-10-25 | 35 |  |  | 11.8d |  |  | FA [80%] | 6h |  |
| 37 | 1.6.1.8 | Mensaje de Información para Usuario | 0.31d? | 2007-10-25 | 2007-10-26 | 34 |  |  | 11.8d | 0d |  | FA [80%] | 2h |  |
| 38 | 1.6.1.9 | Encabezado para Mail | 0.31d? | 2007-10-26 | 2007-10-26 | 37 |  |  | 11.8d | 0d |  | FA [80%] | 2h |  |
| 39 | 1.6.1.10 | **Informacion Util** | 1.41d? | 2007-10-26 | 2007-10-29 |  |  |  | 11.8d |  |  |  | 9h |  |
| 40 | 1.6.1.10.1 | **Servicios** | 1.25d? | 2007-10-26 | 2007-10-29 |  |  |  | 11.8d | 0d |  |  | 8h |  |
| 41 | 1.6.1.10.1.1 | Buscador | 0.62d? | 2007-10-26 | 2007-10-29 | 38 |  |  | 11.8d | 0d |  | FA [80%] | 4h |  |
| 42 | 1.6.1.10.1.2 | Pagina Detalle | 0.62d? | 2007-10-29 | 2007-10-29 | 41 |  |  | 11.8d |  |  | FA [80%] | 4h |  |
| 43 | 1.6.1.10.2 | Plantilla para Teléfonos | 0.16d? | 2007-10-29 | 2007-10-29 | 40 |  |  | 11.8d |  |  | FA [80%] | 1h |  |
| 44 | 1.6.1.11 | **Diseño Eventos** | 26.59d? | 2007-09-21 A | 2007-10-31 |  | 36% | 16.92d? | 6.24d | 0d |  |  | 11h | 4h |
| 45 | 1.6.1.11.1 | Listado de Eventos | 0.31d? | 2007-09-21 A | 2007-09-21 A | 24 | 100% |  |  |  |  | FA [80%] | 2h | 2h |
| 46 | 1.6.1.11.2 | Detalle de los Eventos | 0.31d? | 2007-09-21 A | 2007-09-24 A | 45 | 100% |  |  |  |  | FA [80%] | 2h | 2h |
| 47 | 1.6.1.11.3 | Planilla de Inscripción | 0.47d? | 2007-10-30 | 2007-10-30 |  |  |  | 6.24d | 0d | start no earlier than 2007-10-30 | FA [80%] | 3h |  |
| 48 | 1.6.1.11.4 | Proforma de Pago de Evento | 0.62d? | 2007-10-30 | 2007-10-31 | 47 |  |  | 6.24d |  |  | FA [80%] | 4h |  |

| ID | WBS | Task | Duration | Start | Finish | Predecessors | Complete | Remaining | Total slack | Free slack | Constraint | Resources | Work | Actual work |
| --- | --- | --- | --- | --- | --- | --- | --- | --- | --- | --- | --- | --- | --- | --- |
| 49 | 1.6.1.12 | **Formatos** | 0.31d? | 2007-10-31 | 2007-10-31 |  |  |  | 6.24d | 0d |  |  | 2h |  |
| 50 | 1.6.1.12.1 | Lista de documentos disponibles para ser descargados | 0.31d? | 2007-10-31 | 2007-10-31 | 44 |  |  | 6.24d |  |  | FA [80%] | 2h |  |
| 51 | 1.6.1.13 | **Herramientas** | 1.56d? | 2007-10-31 | 2007-11-01 |  |  |  | 6.24d | 0d |  |  | 10h |  |
| 52 | 1.6.1.13.1 | Calculadora de Inflacion | 0.78d? | 2007-10-31 | 2007-11-01 | 49 |  |  | 6.24d | 0d |  | FA [80%] | 5h |  |
| 53 | 1.6.1.13.2 | Calculadora Financiera | 0.78d? | 2007-11-01 | 2007-11-01 | 52 |  |  | 6.24d |  |  | FA [80%] | 5h |  |
| 54 | 1.6.1.14 | **Plantillas de Contenido** | 2.5d? | 2007-11-01 | 2007-11-06 |  |  |  | 6.24d |  |  |  | 16h |  |
| 55 | 1.6.1.14.1 | Plantilla 1 | 0.62d? | 2007-11-01 | 2007-11-02 | 51 |  |  | 6.24d | 0d |  | FA [80%] | 4h |  |
| 56 | 1.6.1.14.2 | Plantilla 2 | 0.62d? | 2007-11-02 | 2007-11-05 | 55 |  |  | 6.24d | 0d |  | FA [80%] | 4h |  |
| 57 | 1.6.1.14.3 | Plantilla 3 | 0.62d? | 2007-11-05 | 2007-11-05 | 56 |  |  | 6.24d | 0d |  | FA [80%] | 4h |  |
| 58 | 1.6.1.14.4 | Plantilla 4 | 0.62d? | 2007-11-05 | 2007-11-06 | 57 |  |  | 6.24d |  |  | FA [80%] | 4h |  |
| 59 | 1.6.2 | **Net2Client** | 2.5d? | 2007-11-06 | 2007-11-08 |  |  |  | 6.24d | 0d |  |  | 10h |  |
| 60 | 1.6.2.1 | Revision y Adaptacion de CSS de Backoffice | 2.5d? | 2007-11-06 | 2007-11-08 | 12 |  |  | 6.24d |  |  | FA [50%] | 10h |  |
| 61 | 1.6.3 | Adaptacion de Hoja a Firefox | 6d? | 2007-11-08 | 2007-11-16 | 59 |  |  | 6.24d |  |  | FA [50%] | 24h |  |
| 62 | 1.7 | **Desarrollo y Configuración de Funcionalidades** | 44d? | 2007-09-11 A | 2007-11-12 |  | 62% | 16.59d? | 0d |  |  |  | 274h | 159.2h |
| 63 | 1.7.1 | **Análisis y Diseño de funcionalidades y backoffice** | 19d | 2007-09-11 A | 2007-10-05 A |  | 100% |  |  |  |  |  | 24h | 24h |
| 64 | 1.7.1.1 | Análisis | 17d | 2007-09-11 A | 2007-10-05 A |  | 100% |  |  |  | start no earlier than 2007-09-11 | DS1 [10%]; GP [10%] | 16h | 16h |
| 65 | 1.7.1.2 | Modelaje de Base de Datos | 7d | 2007-09-17 A | 2007-09-25 A |  | 100% |  |  |  | start no earlier than 2007-09-17 | GP [10%]; DS1 [10%] | 8h | 8h |
| 66 | 1.7.2 | **Funcionalidades del Sitio Web** | 42d? | 2007-09-13 A | 2007-11-12 |  | 45% | 23.04d? | 0d |  |  |  | 250h | 135.2h |
| 67 | 1.7.2.1 | **BackOffice** | 31.19d? | 2007-09-13 A | 2007-10-29 |  | 81% | 5.81d? | 10.81d |  |  |  | 44h | 35.2h |
| 68 | 1.7.2.1.1 | Registro y Actualización de Cursos | 0.62d? | 2007-09-13 A | 2007-09-13 |  | 80% | 0.12d? | 41.38d |  | start no earlier than 2007-09-13 | DS3 [80%] | 4h | 3.2h |
| 69 | 1.7.2.1.2 | Creación y Configuración de Salas | 0.71d? | 2007-09-17 A | 2007-09-17 A |  | 100% |  |  |  | start no earlier than 2007-09-17 | DS1 [70%] | 4h | 4h |
| 70 | 1.7.2.1.3 | Registro de Artículos | 1.67d? | 2007-09-17 A | 2007-09-19 A | 69 | 100% |  |  |  |  | DS1 [60%] | 8h | 8h |
| 71 | 1.7.2.1.4 | Administración de Banners | 1.25d? | 2007-09-25 A | 2007-09-26 A | 96 | 100% |  |  |  |  | DS1 [80%] | 8h | 8h |
| 72 | 1.7.2.1.5 | Manejo de Contenido de Artículos de Blogs | 1.25d | 2007-09-27 A | 2007-10-01 A | 79 | 100% |  |  |  |  | DS1 [80%] | 8h | 8h |
| 73 | 1.7.2.1.6 | Módulo Contáctenos | 0.62d? | 2007-10-03 A | 2007-10-04 A | 97 | 100% |  |  |  |  | DS1 [80%] | 4h | 4h |
| 74 | 1.7.2.1.7 | Registro de Servicios | 0.62d? | 2007-10-26 | 2007-10-29 | 87 |  |  | 9.56d | 0d |  | DS1 [80%] | 4h |  |
| 75 | 1.7.2.1.8 | Registro de Aliados | 0.62d? | 2007-10-25 | 2007-10-25 |  |  |  | 9.56d | 0d | start no earlier than 2007-10-25 | DS1 [80%] | 4h |  |

| ID | WBS | Task | Duration | Start | Finish | Predecessors | Complete | Remaining | Total slack | Free slack | Constraint | Resources | Work | Actual work |
| --- | --- | --- | --- | --- | --- | --- | --- | --- | --- | --- | --- | --- | --- | --- |
| 76 | 1.7.2.2 | **General** | 21.24d? | 2007-09-26 A | 2007-10-26 |  | 48% | 11.08d? | 1.25d |  |  |  | 34h | 22h |
| 77 | 1.7.2.2.1 | Registro de Cliente | 2.5d | 2007-10-23 | 2007-10-25 |  |  |  | 1.25d | 0d | start no earlier than 2007-10-23 | DS2 [40%] | 8h |  |
| 78 | 1.7.2.2.2 | Login | 1.25d? | 2007-10-25 | 2007-10-26 | 77 |  |  | 1.25d | 0d |  | DS2 [40%] | 4h |  |
| 79 | 1.7.2.2.3 | Banners | 1.25d? | 2007-09-26 A | 2007-09-27 A | 71 | 100% |  |  |  |  | DS1 [80%] | 8h | 8h |
| 80 | 1.7.2.2.4 | Contáctanos | 0.39d? | 2007-10-04 A | 2007-10-04 A | 73 | 100% |  |  |  |  | DS1 [80%] | 2.5h | 2.5h |
| 81 | 1.7.2.2.5 | Tópico de Interés | 0.39d? | 2007-10-04 A | 2007-10-04 A | 80 | 100% |  |  |  |  | DS1 [80%] | 2.5h | 2.5h |
| 82 | 1.7.2.2.6 | Buscador General | 0.62d? | 2007-10-11 A | 2007-10-11 A | 98 | 100% |  |  |  |  | DS1 [80%] | 4h | 4h |
| 83 | 1.7.2.2.7 | Encuestas | 0.78d? | 2007-10-02 A | 2007-10-02 A | 88 | 100% |  |  |  |  | DS3 [80%] | 5h | 5h |
| 84 | 1.7.2.3 | **Página Principal** | 26.18d? | 2007-09-19 A | 2007-10-26 |  | 57% | 11.22d? | 9.56d |  |  |  | 14h | 8h |
| 85 | 1.7.2.3.1 | Lo último (artículos de información recientes) | 0.62d? | 2007-09-19 A | 2007-09-24 A | 70 | 100% |  |  |  |  | DS1 [80%] | 4h | 4h |
| 86 | 1.7.2.3.2 | Enlaces a las salas | 0.62d? | 2007-10-04 A | 2007-10-05 A | 81 | 100% |  |  |  |  | DS1 [80%] | 4h | 4h |
| 87 | 1.7.2.3.3 | Aliados (5 random) | 0.94d? | 2007-10-25 | 2007-10-26 | 75 |  |  | 9.56d | 0d |  | DS1 [80%] | 6h |  |
| 88 | 1.7.2.4 | **Eventos** | 41.38d? | 2007-09-13 A | 2007-11-12 |  | 34% | 27.38d? | 0d |  |  |  | 72h | 28h |
| 89 | 1.7.2.4.1 | Calendario de Eventos | 5d? | 2007-09-13 A | 2007-09-20 A | 68 | 100% |  |  |  |  | DS3 [60%] | 24h | 24h |
| 90 | 1.7.2.4.2 | Publicación de Cursos | 0.62d? | 2007-09-20 A | 2007-09-21 A | 89 | 100% |  |  |  |  | DS3 [80%] | 4h | 4h |
| 91 | 1.7.2.4.3 | Inscripción en Evento | 5d? | 2007-10-29 | 2007-11-02 |  |  |  | 0d |  | start no earlier than 2007-10-29 | DS3 [50%] | 20h |  |
| 92 | 1.7.2.4.4 | Proforma de Pago | 2d? | 2007-11-05 | 2007-11-06 | 91 |  |  | 0d |  |  | DS3 [50%] | 8h |  |
| 93 | 1.7.2.4.5 | Reservación de Cupo | 2d? | 2007-11-07 | 2007-11-08 | 92 |  |  | 0d |  |  | DS3 [50%] | 8h |  |
| 94 | 1.7.2.4.6 | Envío por email de listado de Inscritos al Organizador | 2d? | 2007-11-09 | 2007-11-12 | 93 |  |  | 0d |  |  | DS3 [50%] | 8h |  |
| 95 | 1.7.2.5 | **Salas** | 13.28d? | 2007-09-24 A | 2007-10-11 A |  | 100% |  |  |  |  |  | 42h | 42h |
| 96 | 1.7.2.5.1 | Lo Último (los 6 elementos de información recientes) | 1.25d? | 2007-09-24 A | 2007-09-25 A | 85 | 100% |  |  |  |  | DS1 [80%] | 8h | 8h |
| 97 | 1.7.2.5.2 | Blog | 2.5d? | 2007-10-01 A | 2007-10-03 A | 72 | 100% |  |  |  |  | DS1 [50%] | 10h | 10h |
| 98 | 1.7.2.5.3 | Buscador | 3.75d? | 2007-10-05 A | 2007-10-11 A | 86 | 100% |  |  |  |  | DS1 [80%] | 24h | 24h |
| 99 | 1.7.2.6 | **Envío de Boletin** | 10d? | 2007-10-26 | 2007-11-09 |  |  |  | 1.25d |  |  |  | 32h |  |
| 100 | 1.7.2.6.1 | Desarrollo aplicación | 7.5d? | 2007-10-26 | 2007-11-07 | 78 |  |  | 1.25d | 0d |  | DS2 [40%] | 24h |  |
| 101 | 1.7.2.6.2 | Documentación Técnica | 1.25d? | 2007-11-07 | 2007-11-08 | 100 |  |  | 1.25d | 0d |  | DS2 [40%] | 4h |  |
| 102 | 1.7.2.6.3 | Guia de Usuario | 1.25d? | 2007-11-08 | 2007-11-09 | 101 |  |  | 1.25d |  |  | DS2 [40%] | 4h |  |

| ID | WBS | Task | Duration | Start | Finish | Predecessors | Total slack | Free slack | Constraint | Resources | Work |
| --- | --- | --- | --- | --- | --- | --- | --- | --- | --- | --- | --- |
| 103 | 1.7.2.7 | **Información Útil** | 5.44d? | 2007-10-29 | 2007-11-05 |  | 5.38d |  |  |  | 12h |
| 104 | 1.7.2.7.1 | Herramientas | 0.62d? | 2007-11-05 | 2007-11-05 |  | 5.38d |  | start no earlier than 2007-11-05 | DS3 [80%] | 4h |
| 105 | 1.7.2.7.2 | Servicios | 1.25d? | 2007-10-29 | 2007-10-30 | 74 | 9.56d | 0d |  | DS1 [80%] | 8h |
| 106 | 1.8 | Carga de datos de Clientes en .CSV | 1.5d? | 2007-10-30 | 2007-10-31 | 105 | 18.27d |  |  | DS1 | 12h |
| 107 | 1.9 | Pruebas Internas y ajustes | 1.54d | 2007-11-13 | 2007-11-14 | 66 | 0d |  |  | DS1 [50%]; GP [5%]; DS3 [25%] | 8h |
| 108 | 1.10 | Pruebas de Certificación por parte del Cliente | 1d | 2007-11-14 | 2007-11-15 | 107 | 0.54d | 0d |  |  |  |
| 109 | 1.11 | Pase a Producción | 1d | 2007-11-15 | 2007-11-16 | 108 | 0.54d | 0d |  | OP | 8h |
| 110 | 1.12 | El sitio Web ya puede ser utilizado com Piloto | 1d? | 2007-11-16 | 2007-11-19 | 109 | 5.67d |  |  |  |  |
| 111 | 1.13 | Guia de Usuario BackOffice | 6.67d | 2007-11-14 | 2007-11-23 | 107 | 0d |  |  | GP [15%] | 8h |
| 112 | 1.14 | Inducción (preparación y adiestramiento) | 1d | 2007-11-23 | 2007-11-26 | 111 | 0d |  |  | GP | 8h |
| 113 | 1.15 | Registro de Quién es Quién | 2.5d? | 2007-11-16 | 2007-11-21 | 109 | 0.54d | 0d |  | DS2 [40%] | 8h |
| 114 | 1.16 | Despliegue de Quién es quién | 3.12d? | 2007-11-21 | 2007-11-26 | 113 | 0.54d | 0d |  | DS2 [40%] | 10h |
| 115 | 1.17 | Configuración dominio Web | 0.5d? | 2007-11-26 | 2007-11-26 | 114 | 0.54d |  |  | OP | 4h |
| 116 | 1.18 | **Gerencia de Proyectos** | 58.83d? | 2007-09-04 | 2007-11-27 |  | 0d |  |  |  | 39h |
| 117 | 1.18.1 | Control y Seguimiento | 55.36d? | 2007-09-04 | 2007-11-21 | 2 | 3.47d |  |  | GP [7%] | 31h |
| 118 | 1.18.2 | Cierre | 1d? | 2007-11-26 | 2007-11-27 | 112 | 0d |  |  | GP | 8h |
